# 2014 Support Pack Implementation Project

Schedule from MS Project, 2014-08-15 to 2015-02-02, A marks actual dates.

## Calendars

- Standard: Mon-Fri 08:00-12:00, 13:00-17:00; Sat-Sun off.
- 24 Hours: Mon-Sun 00:00-24:00.

## Resources

| Resource |
| --- |
| ERP Manager |
| PM |
| Team Lead |
| Testing Coordinator |
| R3 |
| TC |
| Transport Coordinator |
| Testing Coordinator - HR |
| Testing Coordinator - FI |
| TranC |
| TransC |
| TestC - HR |
| TestC - FI |
| TestC-HR |
| TestC-FI |
| Team Lead-HR |
| Team Lead-FI |
| IDD |
| QA |
| ABAP Lead |
| BA1 |
| DW |
| R3-1 |
| R3-2 |
| R3-3 |
| ABAP |
| FIN |
| log |
| EHS |
| HRP |
| Bus |
| SAP |
| Core |
| All |
| BC |
| IST-SAP |
| R3-4 |
| QA-4 |
| Bus-Val |
| FIN-1 |
| LOG-1 |
| EHS-1 |
| FIN-Team |
| Log-Team |
| EHS-Team |
| HRP-Team |
| OIS |
| OPS |
| SO |

## Schedule

| ID | WBS | Task | Type | Duration | Start | Finish | Predecessors | Complete | Remaining | Total slack | Free slack | Constraint | Resources | Work | Actual work |
| --- | --- | --- | --- | --- | --- | --- | --- | --- | --- | --- | --- | --- | --- | --- | --- |
| 1 | 1 | **Project Preparation & Planning** |  | 90d | 2014-08-15 08:00 A | 2014-12-19 08:00 |  | 45% | 49.46d | 31.12d |  |  |  | 474h | 368h |
| 2 | 1.1 | **The Dates** |  | 64d | 2014-09-22 08:00 A | 2014-12-19 08:00 |  | 3% | 62.4d | 31.12d |  |  |  |  |  |
| 3 | 1.1.1 | SP Release Date | milestone | 0h | 2014-10-09 08:00 | 2014-10-09 08:00 |  |  |  | 0d |  | start no earlier than 2014-10-09 08:00 |  |  |  |
| 4 | 1.1.2 | Holiday: Columbus Day | milestone | 0h | 2014-10-13 17:00 | 2014-10-13 17:00 |  |  |  | 79.12d | 0d | finish no earlier than 2014-10-13 17:00 |  |  |  |
| 5 | 1.1.3 | SP Freeze |  | 38d | 2014-10-20 08:00 | 2014-12-10 17:00 |  |  |  | 37.12d |  | start no earlier than 2014-10-20 08:00 |  |  |  |
| 6 | 1.1.4 | Go-live Date | milestone | 0h | 2014-12-08 08:00 | 2014-12-08 08:00 |  |  |  | 40.12d |  | start no earlier than 2014-12-08 08:00 |  |  |  |
| 7 | 1.1.5 | First Calendar 2015 Payroll (RDBP) | milestone | 0h | 2014-12-19 08:00 | 2014-12-19 08:00 |  |  |  | 31.12d | 0d | start no earlier than 2014-12-19 08:00 |  |  |  |
| 8 | 1.1.6 | PS1 Snapshot for SF3 (9/22/2014:23:59am) |  | 1d | 2014-09-22 08:00 A | 2014-09-22 17:00 A |  | 100% |  |  |  | start no earlier than 2014-09-22 08:00 |  |  |  |
| 9 | 1.1.7 | PS1 Snapshot for Test Environment (SH2 - 10/20/2014) |  | 1d | 2014-10-20 08:00 | 2014-10-20 17:00 |  |  |  | 74.12d |  | start no earlier than 2014-10-20 08:00 |  |  |  |
| 10 | 1.2 | **Appoint project team, define roles and responsibilities** |  | 39d | 2014-08-15 08:00 A | 2014-10-08 17:00 A |  | 100% |  |  |  |  |  | 249h | 249h |
| 11 | 1.2.1 | Appoint project manager |  | 1h | 2014-08-15 08:00 A | 2014-08-15 09:00 A |  | 100% |  |  |  |  | ERP Manager | 1h | 1h |
| 12 | 1.2.2 | Define project team, member roles and responsibilities |  | 5d | 2014-08-18 09:00 A | 2014-08-25 09:00 A | 11FS+1d | 100% |  |  |  |  | PM | 40h | 40h |
| 13 | 1.2.3 | Appoint project team members (core team/testing coordinators/extended team, etc …) |  | 3d | 2014-08-25 09:00 A | 2014-08-28 09:00 A | 12 | 100% |  |  |  |  | PM | 24h | 24h |
| 14 | 1.2.4 | Notify project team members of their role |  | 1d | 2014-08-29 09:00 A | 2014-09-01 09:00 A | 13FS+1d | 100% |  |  |  |  | PM; Team Lead-HR; Team Lead-FI | 24h | 24h |
| 15 | 1.2.5 | Update business owner list with new / changed owners |  | 10d | 2014-09-25 08:00 A | 2014-10-08 17:00 A | 83SS+1d | 100% |  |  |  |  | TestC-FI; TestC-HR | 160h | 160h |
| 16 | 1.3 | **Develop Project Plan** |  | 23.21d | 2014-08-15 09:00 A | 2014-09-17 10:40 A | 11 | 100% |  |  |  |  |  | 112h | 112h |
| 17 | 1.3.1 | Determine support package availability date |  | 1d | 2014-08-15 09:00 A | 2014-08-18 09:00 A |  | 100% |  |  |  |  | PM | 8h | 8h |
| 18 | 1.3.2 | Determine desired support package & enhancement package levels |  | 1d | 2014-08-18 09:00 A | 2014-08-19 09:00 A | 17 | 100% |  |  |  |  | PM | 8h | 8h |
| 19 | 1.3.3 | Determine dates for production freeze |  | 1d | 2014-09-01 10:40 A | 2014-09-02 10:40 A | 23 | 100% |  |  |  |  | PM | 8h | 8h |
| 20 | 1.3.4 | Define high level plan, milestones, deliverables |  | 5d | 2014-09-02 10:40 A | 2014-09-09 10:40 A | 19 | 100% |  |  |  |  | PM | 40h | 40h |
| 21 | 1.3.5 | Identify Pending Projects that may collide with the project |  | 1d | 2014-09-09 10:40 A | 2014-09-10 10:40 A | 20 | 100% |  |  |  |  | PM | 8h | 8h |
| 22 | 1.3.6 | Review any development/cleanup work that can be included in the project |  | 5d | 2014-09-10 10:40 A | 2014-09-17 10:40 A | 21 | 100% |  |  |  |  | BC | 40h | 40h |
| 23 | 1.4 | **Define environments, refresh schedule, support pack plan** |  | 2.12d | 2014-08-28 09:00 A | 2014-09-01 10:00 A |  | 100% |  |  |  |  |  | 7h | 7h |
| 24 | 1.4.1 | Identify environments for Staging, and TST (DEV not refreshed) |  | 1h | 2014-08-28 09:00 A | 2014-08-28 10:00 A | 13 | 100% |  |  |  |  | R3; PM | 2h | 2h |
| 25 | 1.4.2 | Develop/update env landscape document |  | 1h | 2014-08-28 10:00 A | 2014-08-28 11:00 A | 24 | 100% |  |  |  |  | PM | 1h | 1h |
| 26 | 1.4.3 | Determine production snapshot dates for STG, TST |  | 1h | 2014-09-01 09:00 A | 2014-09-01 10:00 A | 14 | 100% |  |  |  |  | TestC-FI; TestC-HR | 2h | 2h |
| 27 | 1.4.4 | Determine dates for STG, TST refreshes |  | 1h | 2014-09-01 09:00 A | 2014-09-01 10:00 A | 14 | 100% |  |  |  |  | R3; PM | 2h | 2h |

| ID | WBS | Task | Duration | Start | Finish | Predecessors | Complete | Remaining | Total slack | Free slack | Resources | Work | Actual work |
| --- | --- | --- | --- | --- | --- | --- | --- | --- | --- | --- | --- | --- | --- |
| 28 | 1.5 | **Project Execution Setup Tasks** | 16.12d | 2014-08-15 08:00 A | 2014-09-08 09:00 A |  | 100% |  |  |  |  |  |  |
| 29 | 1.5.1 | Set up project in RT Test Queue | 1d | 2014-09-03 09:00 A | 2014-09-04 09:00 A | 10 | 100% |  |  |  |  |  |  |
| 30 | 1.5.2 | Verify/Assign Queue watchers | 1d | 2014-09-04 09:00 A | 2014-09-05 09:00 A | 29 | 100% |  |  |  |  |  |  |
| 31 | 1.5.3 | Set up RT query for project issues | 1d | 2014-09-05 09:00 A | 2014-09-08 09:00 A | 30 | 100% |  |  |  |  |  |  |
| 32 | 1.5.4 | Verify/Assign Transport watchers | 1d | 2014-09-04 09:00 A | 2014-09-05 09:00 A | 29 | 100% |  |  |  |  |  |  |
| 33 | 1.5.5 | Schedule meeting w/ QA | 1d | 2014-09-03 09:00 A | 2014-09-04 09:00 A | 10 | 100% |  |  |  |  |  |  |
| 34 | 1.5.6 | Meet w/ QA (review project) | 1d | 2014-09-04 09:00 A | 2014-09-05 09:00 A | 33 | 100% |  |  |  |  |  |  |
| 35 | 1.5.7 | Schedule meeting w/ Testing Coordinators | 1d | 2014-08-15 08:00 A | 2014-09-04 08:12 A | 10 | 100% |  |  |  |  |  |  |
| 36 | 1.5.8 | Meet w/ Testing Coords (Define Testing Strategy & Technology) | 1d | 2014-09-04 08:12 A | 2014-09-05 08:12 A | 35 | 100% |  |  |  |  |  |  |
| 37 | 1.6 | **Develop cut-over plan** | 20.38d | 2014-11-03 08:00 | 2014-12-01 11:00 | 273 |  |  | 44.75d |  |  | 106h |  |
| 38 | 1.6.1 | Identify resources | 1d | 2014-11-03 08:00 | 2014-11-03 17:00 |  |  |  | 64.12d |  | PM | 8h |  |
| 39 | 1.6.2 | Prep cut-over plan document | 4h | 2014-11-03 08:00 | 2014-11-03 12:00 |  |  |  | 64.62d |  | PM | 4h |  |
| 40 | 1.6.3 | Review transports resulting from SPAU | 4h | 2014-11-03 08:00 | 2014-11-03 12:00 |  |  |  | 64.62d |  | Core | 4h |  |
| 41 | 1.6.4 | Review transports resulting from Unit Test | 4h | 2014-11-03 08:00 | 2014-11-03 12:00 | 272 |  |  | 44.75d | 0d | Core | 4h |  |
| 42 | 1.6.5 | Review transports resulting from SIT/UAT | 4h | 2014-11-19 08:00 | 2014-11-19 12:00 | 317 |  |  | 52.62d |  | Core | 4h |  |
| 43 | 1.6.6 | Schedule cut-over plan meeting | 1h | 2014-11-03 13:00 | 2014-11-03 14:00 | 41 |  |  | 44.75d | 0d | PM | 1h |  |
| 44 | 1.6.7 | Cut-over plan meeting | 2h | 2014-11-17 14:00 | 2014-11-17 16:00 | 43FS+10d |  |  | 44.75d | 0d | Core | 2h |  |
| 45 | 1.6.8 | Review/update communication email list sap-vailidation-team@mit.edu | 1h | 2014-11-17 16:00 | 2014-11-17 17:00 | 44 |  |  | 54.12d |  | PM; TestC - HR; TestC - FI | 3h |  |
| 46 | 1.6.9 | Develop cut-over plan & publish | 9d | 2014-11-17 16:00 | 2014-11-28 16:00 | 44 |  |  | 44.75d | 0d | PM | 72h |  |
| 47 | 1.6.10 | Finalize cut-over plan & publish | 4h | 2014-11-28 16:00 | 2014-12-01 11:00 | 46 |  |  | 44.75d |  | Core | 4h |  |
| 48 | 2 | **Communication** | 121.12d | 2014-08-15 08:00 A | 2015-02-02 09:00 |  | 75% | 29.93d | 0d |  |  | 267h | 265h |
| 49 | 2.1 | Develop project wiki | 5d | 2014-08-19 09:00 A | 2014-08-26 09:00 A | 11FS+2d | 100% |  |  |  | PM; IDD; QA | 120h | 120h |
| 50 | 2.2 | Schedule IS&T (Admin Systems) project kick-off meeting | 2h | 2014-08-15 08:00 A | 2014-08-15 10:00 A |  | 100% |  |  |  | PM; ERP Manager | 4h | 4h |
| 51 | 2.3 | Schedule SAPbiz project kick-off meeting (last meeting of September) | 1h | 2014-08-19 09:00 A | 2014-08-19 10:00 A | 11FS+2d | 100% |  |  |  | PM | 1h | 1h |
| 52 | 2.4 | Schedule Steering Committee Meeting | 1d | 2014-08-21 09:00 A | 2014-08-22 09:00 A | 11FS+4d | 100% |  |  |  | PM | 8h | 8h |
| 53 | 2.5 | Schedule Core Team Meeting(s) | 1d | 2014-09-02 09:00 A | 2014-09-03 09:00 A | 14FS+1d | 100% |  |  |  | PM | 8h | 8h |
| 54 | 2.6 | Review/update communication email list sap-upgrade-core@mit.edu | 1h | 2014-09-03 09:00 A | 2014-09-03 10:00 A | 15 | 100% |  |  |  | PM | 1h | 1h |
| 55 | 2.7 | Review/update communication email list ist-sap@mit.edu | 1h | 2014-09-03 10:00 A | 2014-09-03 11:00 A | 54 | 100% |  |  |  | PM | 1h | 1h |
| 56 | 2.8 | Review/update communication email list sap-upgrade-steering-committee | 1d | 2014-08-15 08:00 A | 2014-08-15 17:00 A |  | 100% |  |  |  | PM | 8h | 8h |
| 57 | 2.9 | Prepare Project Presentation for the Steering Committee | 2d | 2014-08-22 09:00 A | 2014-08-26 09:00 A | 52 | 100% |  |  |  | PM | 16h | 16h |
| 58 | 2.10 | Prepare Project Presentation for IS&T | 2d | 2014-08-26 09:00 A | 2014-08-28 09:00 A | 57 | 100% |  |  |  | PM; QA; R3 | 48h | 48h |
| 59 | 2.11 | Prepare Project Presentation for SAPbiz | 2d | 2014-08-28 09:00 A | 2014-09-01 09:00 A | 58 | 100% |  |  |  | PM; QA; R3 | 48h | 48h |
| 60 | 2.12 | IS&T Kick off meeting | 2h | 2014-09-09 10:40 A | 2014-09-09 13:40 A | 20 | 100% |  |  |  | IST-SAP | 2h | 2h |

| ID | WBS | Task | Duration | Start | Finish | Complete | Remaining | Total slack | Constraint |
| --- | --- | --- | --- | --- | --- | --- | --- | --- | --- |
| 61 | 2.13 | **Steering Committee Meeting** | 100.12d | 2014-09-15 08:00 A | 2015-02-02 09:00 | 20% | 80.1d | 0d |  |
| 62 | 2.13.1 | Steering Committee Meeting 1 | 1h | 2014-09-15 08:00 A | 2014-09-15 09:00 A | 100% |  |  | start no earlier than 2014-09-15 08:00 |
| 63 | 2.13.2 | Steering Committee Meeting 2 | 1h | 2014-11-03 08:00 | 2014-11-03 09:00 |  |  | 65d | start no earlier than 2014-11-03 08:00 |
| 64 | 2.13.3 | Steering Committee Meeting 3 | 1h | 2014-12-01 08:00 | 2014-12-01 09:00 |  |  | 45d | start no earlier than 2014-12-01 08:00 |
| 65 | 2.13.4 | Steering Committee Meeting 4 | 1h | 2015-01-05 08:00 | 2015-01-05 09:00 |  |  | 20d | start no earlier than 2015-01-05 08:00 |
| 66 | 2.13.5 | Steering Committee Meeting 5 | 1h | 2015-02-02 08:00 | 2015-02-02 09:00 |  |  | 0d | start no earlier than 2015-02-02 08:00 |
| 67 | 2.14 | **Core Team Meeting** | 65.12d | 2014-09-15 08:00 A | 2014-12-15 09:00 | 14% | 55.82d | 35d |  |
| 68 | 2.14.1 | Core Team Meeting 1 | 1h | 2014-09-15 08:00 A | 2014-09-15 09:00 A | 100% |  |  | start no earlier than 2014-09-15 08:00 |
| 69 | 2.14.2 | Core Team Meeting 2 | 1h | 2014-09-22 08:00 A | 2014-09-22 09:00 A | 100% |  |  | start no earlier than 2014-09-22 08:00 |
| 70 | 2.14.3 | Core Team Meeting 3 | 1h | 2014-09-29 08:00 | 2014-09-29 09:00 |  |  | 90d | start no earlier than 2014-09-29 08:00 |
| 71 | 2.14.4 | Core Team Meeting 4 | 1h | 2014-10-06 08:00 | 2014-10-06 09:00 |  |  | 85d | start no earlier than 2014-10-06 08:00 |
| 72 | 2.14.5 | Core Team Meeting 5 | 1h | 2014-10-13 08:00 | 2014-10-13 09:00 |  |  | 80d | start no earlier than 2014-10-13 08:00 |
| 73 | 2.14.6 | Core Team Meeting 6 | 1h | 2014-10-20 08:00 | 2014-10-20 09:00 |  |  | 75d | start no earlier than 2014-10-20 08:00 |
| 74 | 2.14.7 | Core Team Meeting 7 | 1h | 2014-10-27 08:00 | 2014-10-27 09:00 |  |  | 70d | start no earlier than 2014-10-27 08:00 |
| 75 | 2.14.8 | Core Team Meeting 8 | 1h | 2014-11-03 08:00 | 2014-11-03 09:00 |  |  | 65d | start no earlier than 2014-11-03 08:00 |
| 76 | 2.14.9 | Core Team Meeting 9 | 1h | 2014-11-10 08:00 | 2014-11-10 09:00 |  |  | 60d | start no earlier than 2014-11-10 08:00 |
| 77 | 2.14.10 | Core Team Meeting 10 | 1h | 2014-11-17 08:00 | 2014-11-17 09:00 |  |  | 55d | start no earlier than 2014-11-17 08:00 |
| 78 | 2.14.11 | Core Team Meeting 11 | 1h | 2014-11-24 08:00 | 2014-11-24 09:00 |  |  | 50d | start no earlier than 2014-11-24 08:00 |
| 79 | 2.14.12 | Core Team Meeting 12 | 1h | 2014-12-01 08:00 | 2014-12-01 09:00 |  |  | 45d | start no earlier than 2014-12-01 08:00 |
| 80 | 2.14.13 | Core Team Meeting 13 | 1h | 2014-12-08 08:00 | 2014-12-08 09:00 |  |  | 40d | start no earlier than 2014-12-08 08:00 |
| 81 | 2.14.14 | Core Team Meeting 14 | 1h | 2014-12-15 08:00 | 2014-12-15 09:00 |  |  | 35d | start no earlier than 2014-12-15 08:00 |
| 82 | 2.15 | **SAPbiz Meeting** | 65.25d | 2014-09-24 08:00 A | 2014-12-24 10:00 | 25% | 48.94d | 27.88d |  |
| 83 | 2.15.1 | SAPbiz Meeting 1 | 2h | 2014-09-24 08:00 A | 2014-09-24 10:00 A | 100% |  |  | start no earlier than 2014-09-24 08:00 |
| 84 | 2.15.2 | SAPbiz Meeting 2 | 2h | 2014-10-22 08:00 | 2014-10-22 10:00 |  |  | 72.88d | start no earlier than 2014-10-22 08:00 |
| 85 | 2.15.3 | SAPbiz Meeting 3 | 2h | 2014-11-26 08:00 | 2014-11-26 10:00 |  |  | 47.88d | start no earlier than 2014-11-26 08:00 |
| 86 | 2.15.4 | SAPbiz Meeting 4 | 2h | 2014-12-24 08:00 | 2014-12-24 10:00 |  |  | 27.88d | start no earlier than 2014-12-24 08:00 |

| ID | WBS | Task | Duration | Start | Finish | Predecessors | Complete | Remaining | Total slack | Constraint | Resources | Work |
| --- | --- | --- | --- | --- | --- | --- | --- | --- | --- | --- | --- | --- |
| 87 | 2.16 | **R3 Admin Meeting** | 105.12d | 2014-09-05 08:00 A | 2015-01-30 09:00 |  | 18% | 86.01d | 1d |  |  |  |
| 88 | 2.16.1 | R3 Admin Meeting 1 | 1h | 2014-09-05 08:00 A | 2014-09-05 09:00 A |  | 100% |  |  | start no earlier than 2014-09-05 08:00 |  |  |
| 89 | 2.16.2 | R3 Admin Meeting 2 | 1h | 2014-09-12 08:00 A | 2014-09-12 09:00 A |  | 100% |  |  | start no earlier than 2014-09-12 08:00 |  |  |
| 90 | 2.16.3 | R3 Admin Meeting 3 | 1h | 2014-09-19 08:00 A | 2014-09-19 09:00 A |  | 100% |  |  | start no earlier than 2014-09-19 08:00 |  |  |
| 91 | 2.16.4 | R3 Admin Meeting 4 | 1h | 2014-09-26 08:00 A | 2014-09-26 09:00 A |  | 100% |  |  | start no earlier than 2014-09-26 08:00 |  |  |
| 92 | 2.16.5 | R3 Admin Meeting 5 | 1h | 2014-10-03 08:00 | 2014-10-03 09:00 |  |  |  | 86d | start no earlier than 2014-10-03 08:00 |  |  |
| 93 | 2.16.6 | R3 Admin Meeting 6 | 1h | 2014-10-10 08:00 | 2014-10-10 09:00 |  |  |  | 81d | start no earlier than 2014-10-10 08:00 |  |  |
| 94 | 2.16.7 | R3 Admin Meeting 7 | 1h | 2014-10-17 08:00 | 2014-10-17 09:00 |  |  |  | 76d | start no earlier than 2014-10-17 08:00 |  |  |
| 95 | 2.16.8 | R3 Admin Meeting 8 | 1h | 2014-10-24 08:00 | 2014-10-24 09:00 |  |  |  | 71d | start no earlier than 2014-10-24 08:00 |  |  |
| 96 | 2.16.9 | R3 Admin Meeting 9 | 1h | 2014-10-31 08:00 | 2014-10-31 09:00 |  |  |  | 66d | start no earlier than 2014-10-31 08:00 |  |  |
| 97 | 2.16.10 | R3 Admin Meeting 10 | 1h | 2014-11-07 08:00 | 2014-11-07 09:00 |  |  |  | 61d | start no earlier than 2014-11-07 08:00 |  |  |
| 98 | 2.16.11 | R3 Admin Meeting 11 | 1h | 2014-11-14 08:00 | 2014-11-14 09:00 |  |  |  | 56d | start no earlier than 2014-11-14 08:00 |  |  |
| 99 | 2.16.12 | R3 Admin Meeting 12 | 1h | 2014-11-21 08:00 | 2014-11-21 09:00 |  |  |  | 51d | start no earlier than 2014-11-21 08:00 |  |  |
| 100 | 2.16.13 | R3 Admin Meeting 13 | 1h | 2014-11-28 08:00 | 2014-11-28 09:00 |  |  |  | 46d | start no earlier than 2014-11-28 08:00 |  |  |
| 101 | 2.16.14 | R3 Admin Meeting 14 | 1h | 2014-12-05 08:00 | 2014-12-05 09:00 |  |  |  | 41d | start no earlier than 2014-12-05 08:00 |  |  |
| 102 | 2.16.15 | R3 Admin Meeting 15 | 1h | 2014-12-12 08:00 | 2014-12-12 09:00 |  |  |  | 36d | start no earlier than 2014-12-12 08:00 |  |  |
| 103 | 2.16.16 | R3 Admin Meeting 16 | 1h | 2014-12-19 08:00 | 2014-12-19 09:00 |  |  |  | 31d | start no earlier than 2014-12-19 08:00 |  |  |
| 104 | 2.16.17 | R3 Admin Meeting 17 | 1h | 2014-12-26 08:00 | 2014-12-26 09:00 |  |  |  | 26d | start no earlier than 2014-12-26 08:00 |  |  |
| 105 | 2.16.18 | R3 Admin Meeting 18 | 1h | 2015-01-02 08:00 | 2015-01-02 09:00 |  |  |  | 21d | start no earlier than 2015-01-02 08:00 |  |  |
| 106 | 2.16.19 | R3 Admin Meeting 19 | 1h | 2015-01-09 08:00 | 2015-01-09 09:00 |  |  |  | 16d | start no earlier than 2015-01-09 08:00 |  |  |
| 107 | 2.16.20 | R3 Admin Meeting 20 | 1h | 2015-01-16 08:00 | 2015-01-16 09:00 |  |  |  | 11d | start no earlier than 2015-01-16 08:00 |  |  |
| 108 | 2.16.21 | R3 Admin Meeting 21 | 1h | 2015-01-23 08:00 | 2015-01-23 09:00 |  |  |  | 6d | start no earlier than 2015-01-23 08:00 |  |  |
| 109 | 2.16.22 | R3 Admin Meeting 22 | 1h | 2015-01-30 08:00 | 2015-01-30 09:00 |  |  |  | 1d | start no earlier than 2015-01-30 08:00 |  |  |
| 110 | 2.17 | Communicate cut-over plan | 1h | 2014-11-28 16:00 | 2014-11-28 17:00 | 46 |  |  | 45.12d |  | Core | 1h |
| 111 | 2.18 | Schedule Lessons Learned meeting | 1h | 2015-01-15 08:00 | 2015-01-15 09:00 | 328FS+25d |  |  | 12d |  | PM | 1h |

| ID | WBS | Task | Duration | Start | Finish | Predecessors | Complete | Remaining | Total slack | Free slack | Resources | Work | Actual work |
| --- | --- | --- | --- | --- | --- | --- | --- | --- | --- | --- | --- | --- | --- |
| 112 | 3 | **Develop SAP SP Unit Test db <skip 2014 - not needed>** | 40.83d | 2014-08-15 08:00 A | 2014-10-10 15:40 A |  | 100% |  |  |  |  | 332h | 332h |
| 113 | 3.1 | Determine if new Unit Test db is needed | 1d | 2014-09-09 10:40 A | 2014-09-10 10:40 A | 20 | 100% |  |  |  |  |  |  |
| 114 | 3.2 | Schedule meeting with developer team lead | 1h | 2014-09-10 10:40 A | 2014-09-10 11:40 A | 113 | 100% |  |  |  | PM | 1h | 1h |
| 115 | 3.3 | Define reuirements | 1d | 2014-08-15 08:00 A | 2014-08-15 17:00 A |  | 100% |  |  |  | PM | 8h | 8h |
| 116 | 3.4 | SAP SP Unit Test db meeting | 2h | 2014-09-12 11:40 A | 2014-09-12 14:40 A | 114FS+2d | 100% |  |  |  | PM | 2h | 2h |
| 117 | 3.5 | Assign developer | 1h | 2014-09-12 14:40 A | 2014-09-12 15:40 A | 116 | 100% |  |  |  | IDD | 1h | 1h |
| 118 | 3.6 | Develop SAP SP Unit db | 20d | 2014-09-12 15:40 A | 2014-10-10 15:40 A | 117 | 100% |  |  |  | TestC - HR; TestC - FI | 320h | 320h |
| 119 | 4 | **Test Planning** | 53.88d | 2014-08-25 09:00 A | 2014-11-06 17:00 |  | 8% | 49.48d | 61.12d |  |  | 720h | 83h |
| 120 | 4.1 | Define, document, communicate test case management procedure - templates, process, … | 1d | 2014-10-09 08:00 A | 2014-10-09 17:00 A | 12 | 100% |  |  |  | QA | 8h | 8h |
| 121 | 4.2 | Plan datawarehouse extracts | 1h | 2014-09-01 10:00 A | 2014-10-10 08:40 A | 120 | 100% |  |  |  | R3; PM; DW | 3h | 3h |
| 122 | 4.3 | Publish datawarehouse extract test plan | 1d | 2014-10-10 08:40 | 2014-10-13 08:40 | 121 |  |  | 80.04d |  |  |  |  |
| 123 | 4.4 | **Unit Test Planning (UT)** | 34.6d | 2014-08-25 09:00 A | 2014-10-10 14:49 | 12 | 54% | 15.88d | 80.4d |  |  | 149h | 72h |
| 124 | 4.4.1 | Execute SAP Transaction/Program usage report | 2d | 2014-08-25 09:00 A | 2014-09-30 08:49 A |  | 100% |  |  |  | R3 | 16h | 16h |
| 125 | 4.4.2 | Mirge usage report into SAP SP Unit Test db/google docs | 4h | 2014-09-30 08:49 A | 2014-09-30 13:49 A | 124 | 100% |  |  |  | R3 | 4h | 4h |
| 126 | 4.4.3 | Determine transactions / reports to be tested | 5d | 2014-09-30 13:49 A | 2014-10-07 13:49 | 125 | 50% | 2.5d | 0.75d | 0d | TestC - FI; TestC-HR | 80h | 40h |
| 127 | 4.4.4 | Update SAP SP Unit Test db/google docs | 3d | 2014-10-07 13:49 A | 2014-10-10 13:49 | 126 | 25% | 2.25d | 80.4d | 0d | TestC - FI; TestC-HR | 48h | 12h |
| 128 | 4.4.5 | Publish Unit test plan | 1h | 2014-10-10 13:49 | 2014-10-10 14:49 | 127 |  |  | 80.4d |  | PM | 1h |  |
| 129 | 4.5 | **Update Quality Center (QC) test script catalogs** | 20d | 2014-10-10 08:00 | 2014-11-06 17:00 | 120 |  |  | 61.12d | 0d |  | 560h |  |
| 130 | 4.5.1 | Convert SIT/UAT cases into QC | 20d | 2014-10-10 08:00 | 2014-11-06 17:00 |  |  |  | 61.12d |  | QA | 160h |  |
| 131 | 4.5.2 | Review transaction / report log for new items | 5d | 2014-10-10 08:00 | 2014-10-16 17:00 |  |  |  | 69.12d | 0d | TestC - FI; TestC-HR | 80h |  |
| 132 | 4.5.3 | Update test script catalog with new transactions / reports | 5d | 2014-10-17 08:00 | 2014-10-23 17:00 | 131 |  |  | 69.12d | 0d | TestC - FI; TestC-HR | 80h |  |
| 133 | 4.5.4 | Review test script catalog for missing / old test scripts | 2d | 2014-10-24 08:00 | 2014-10-27 17:00 | 132 |  |  | 69.12d |  | TestC - FI; TestC-HR | 32h |  |
| 134 | 4.5.5 | Create new / update old test scripts | 5d | 2014-10-10 08:00 | 2014-10-16 17:00 | 120 |  |  | 76.12d |  | TestC - FI; TestC-HR | 80h |  |
| 135 | 4.5.6 | Convert test cases to new template | 5d | 2014-10-10 08:00 | 2014-10-16 17:00 | 120 |  |  | 75.12d | 0d | TestC - FI; TestC-HR | 80h |  |
| 136 | 4.5.7 | Financial Team confirms completeness of test script catalog | 1d | 2014-10-17 08:00 | 2014-10-17 17:00 | 135 |  |  | 75.12d |  | FIN-Team | 8h |  |
| 137 | 4.5.8 | Logistics Team confirms completeness of test script catalog | 1d | 2014-10-17 08:00 | 2014-10-17 17:00 | 135 |  |  | 75.12d |  | Log-Team | 8h |  |
| 138 | 4.5.9 | EHS Team confirms completeness of test script catalog | 1d | 2014-10-17 08:00 | 2014-10-17 17:00 | 135 |  |  | 75.12d |  | EHS-Team | 8h |  |
| 139 | 4.5.10 | HR-Payroll Team confirms completeness of test script catalog | 1d | 2014-10-17 08:00 | 2014-10-17 17:00 | 135 |  |  | 75.12d |  | HRP-Team | 8h |  |
| 140 | 4.5.11 | Provide QA w/ FI/LOG/EHS QC user list | 1d | 2014-10-17 08:00 | 2014-10-17 17:00 | 135 |  |  | 75.12d |  | TestC-FI | 8h |  |
| 141 | 4.5.12 | Provide QA w/ HRP QC user list | 1d | 2014-10-17 08:00 | 2014-10-17 17:00 | 135 |  |  | 75.12d |  | TestC-HR | 8h |  |

| ID | WBS | Task | Duration | Start | Finish | Predecessors | Complete | Remaining | Total slack | Free slack | Resources | Work | Actual work |
| --- | --- | --- | --- | --- | --- | --- | --- | --- | --- | --- | --- | --- | --- |
| 142 | 4.6 | **Systems Integration Test Planning (SIT)** | 16.5d | 2014-10-10 08:00 A | 2014-11-03 12:00 | 129SS | 1% | 16.34d | 64.62d |  |  |  |  |
| 143 | 4.6.1 | Send UA test script calatlog to business owners | 4h | 2014-10-10 08:00 A | 2014-10-10 12:00 |  | 50% | 2h | 64.62d | 0d |  |  |  |
| 144 | 4.6.2 | Function Test Leads meet with Functional Areas to review/plan testing (repetitive) | 5d | 2014-10-10 13:00 | 2014-10-17 12:00 | 143 |  |  | 75.62d |  |  |  |  |
| 145 | 4.6.3 | Define business scenarios/tests to be used in SIT (add to QC test lab) | 10d | 2014-10-10 13:00 | 2014-10-24 12:00 | 143 |  |  | 64.62d | 0d |  |  |  |
| 146 | 4.6.4 | Update business scenarios as required | 2d | 2014-10-24 13:00 | 2014-10-28 12:00 | 145 |  |  | 64.62d | 0d |  |  |  |
| 147 | 4.6.5 | QA review of test lab selections | 2d | 2014-10-28 13:00 | 2014-10-30 12:00 | 146 |  |  | 66.62d |  |  |  |  |
| 148 | 4.6.6 | **Functional Teams confirm test plan** | 1d | 2014-10-28 13:00 | 2014-10-29 12:00 | 146 |  |  | 67.62d |  |  |  |  |
| 149 | 4.6.6.1 | Financial Team confirms completeness of business scenarios | 1d | 2014-10-28 13:00 | 2014-10-29 12:00 | 146 |  |  | 67.62d |  |  |  |  |
| 150 | 4.6.6.2 | Logistics Team confirms completeness of business scenarios | 1d | 2014-10-28 13:00 | 2014-10-29 12:00 | 146 |  |  | 67.62d |  |  |  |  |
| 151 | 4.6.6.3 | EHS Team confirms completeness of business scenarios | 1d | 2014-10-28 13:00 | 2014-10-29 12:00 | 146 |  |  | 67.62d |  |  |  |  |
| 152 | 4.6.6.4 | HR-Payroll Team confirms completeness of business scenarios | 1d | 2014-10-28 13:00 | 2014-10-29 12:00 | 146 |  |  | 67.62d |  |  |  |  |
| 153 | 4.6.7 | QA confirms completeness of business scenarios | 1d | 2014-10-28 13:00 | 2014-10-29 12:00 | 146 |  |  | 64.62d | 0d |  |  |  |
| 154 | 4.6.8 | Publish SIT Test Schedule | 1d | 2014-10-29 13:00 | 2014-10-30 12:00 | 153 |  |  | 64.62d | 0d |  |  |  |
| 155 | 4.6.9 | **User Acceptance of SIT Planning** | 2d | 2014-10-30 13:00 | 2014-11-03 12:00 | 154 |  |  | 64.62d |  |  |  |  |
| 156 | 4.6.9.1 | Send UA test script catalog to business owners | 4h | 2014-10-30 13:00 | 2014-10-30 17:00 |  |  |  | 64.62d | 0d |  |  |  |
| 157 | 4.6.9.2 | Business analysts update test script catalogs | 4h | 2014-11-03 08:00 | 2014-11-03 12:00 | 156FS+1d |  |  | 64.62d |  |  |  |  |
| 158 | 5 | **System Admin Preparation** | 15.5d | 2014-09-15 10:00 A | 2014-10-06 15:00 | 23FS+10d | 7% | 14.43d | 84.38d |  |  | 140h | 24h |
| 159 | 5.1 | Review and update action log from previous year | 1d | 2014-09-15 10:00 A | 2014-09-16 10:00 A |  | 100% |  |  |  | PM; R3; ABAP Lead | 24h | 24h |
| 160 | 5.2 | Download HRP SP OSS Note Lists | 1d | 2014-09-15 10:00 | 2014-09-16 10:00 |  |  |  | 84.38d | 0d | PM; BA1 | 16h |  |
| 161 | 5.3 | Format SP OSS Note Lists into a single spreadsheet and post on wiki | 4h | 2014-09-16 10:00 | 2014-09-16 15:00 | 160 |  |  | 84.38d | 0d | BA1 | 4h |  |
| 162 | 5.4 | Solution Manager Update - SM1 sandbox (SPS Level xx -> SPS Level xx) | 3d | 2014-09-15 10:00 | 2014-09-18 10:00 |  |  |  | 91.88d | 0d | R3-4 | 24h |  |
| 163 | 5.5 | Solution Manager Update - SM2 dev/test (SPS Level xx -> SPS Level xx) | 3d | 2014-09-18 10:00 | 2014-09-23 10:00 | 162 |  |  | 91.88d | 0d | R3-4 | 24h |  |
| 164 | 5.6 | Solution Manager Update - PSM production (SPS Level xx -> SPS Level xx) | 2d | 2014-09-23 10:00 | 2014-09-25 10:00 | 163 |  |  | 91.88d |  | R3-4 | 16h |  |
| 165 | 5.7 | Produce Side Effects Report | 2d | 2014-10-02 15:00 | 2014-10-06 15:00 | 161FS+12d |  |  | 84.38d | 0d | R3-1 | 16h |  |
| 166 | 5.8 | Download Enh Packs, SP Stacks, SPs | 2d | 2014-10-02 15:00 | 2014-10-06 15:00 | 165SS |  |  | 84.38d |  | R3-2 | 16h |  |

| ID | WBS | Task | Duration | Start | Finish | Predecessors | Complete | Calendar | Resources | Work | Actual work |
| --- | --- | --- | --- | --- | --- | --- | --- | --- | --- | --- | --- |
| 167 | 6 | **Practice update (SF7) - <SKIP in 2011-14>** | 17.5d | 2014-09-18 10:40 A | 2014-10-13 15:40 A | 158SS+3d | 100% |  |  | 140h | 140h |
| 168 | 6.1 | Identify & Prepare practice system | 13d | 2014-09-18 10:40 A | 2014-10-07 10:40 A |  | 100% |  | R3-1 | 104h | 104h |
| 169 | 6.2 | Apply SAP kernel update | 4h | 2014-10-07 10:40 A | 2014-10-07 15:40 A | 168 | 100% |  | R3-1 | 4h | 4h |
| 170 | 6.3 | Upgrade Oracle db | 8h | 2014-10-07 15:40 A | 2014-10-08 15:40 A | 169 | 100% |  | R3-1 | 8h | 8h |
| 171 | 6.4 | Test Install Support Packs (TBD) | 3d | 2014-10-08 15:40 A | 2014-10-13 15:40 A | 170 | 100% |  | R3-1 | 24h | 24h |
| 172 | 7 | **DB/OS Pre-support Pack Upgrade <skip in 2014>** | 21d | 2014-09-26 08:00 A | 2014-10-26 09:30 A |  | 100% |  |  |  |  |
| 173 | 7.1 | **Upgrade SF2 DB/OS** | 2d | 2014-09-26 08:00 A | 2014-09-29 17:00 A |  | 100% |  |  |  |  |
| 174 | 7.1.1 | Upgrade DB | 1d | 2014-09-26 08:00 A | 2014-09-26 17:00 A | 8FS+3d | 100% |  |  |  |  |
| 175 | 7.1.2 | Upgrade OS | 1d | 2014-09-29 08:00 A | 2014-09-29 17:00 A | 174 | 100% |  |  |  |  |
| 176 | 7.2 | **Refresh SH2** | 1.5d | 2014-09-30 08:00 A | 2014-10-01 12:00 A |  | 100% |  |  |  |  |
| 177 | 7.2.1 | Using PS1 Snapshot for SF3 refrsh SH2 | 1d | 2014-09-30 08:00 A | 2014-09-30 17:00 A | 173 | 100% |  |  |  |  |
| 178 | 7.2.2 | Execute post refresh action log | 4h | 2014-10-01 08:00 A | 2014-10-01 12:00 A | 177 | 100% |  |  |  |  |
| 179 | 7.3 | **Upgrade SH2/SH1 DB/OS** | 6.5d | 2014-10-02 13:00 A | 2014-10-10 17:00 A |  | 100% |  |  |  |  |
| 180 | 7.3.1 | Upgrade SH2 ERP DB | 4h | 2014-10-02 13:00 A | 2014-10-02 17:00 A | 176FS+1d | 100% |  |  |  |  |
| 181 | 7.3.2 | Upgrade SH1 ERP DB | 4h | 2014-10-03 08:00 A | 2014-10-03 12:00 A | 180 | 100% |  |  |  |  |
| 182 | 7.3.3 | Upgrade SH2/SH1 OS (same server) | 1d | 2014-10-03 20:00 A | 2014-10-04 04:00 A | 181FS+1d | 100% | 24 Hours |  |  |  |
| 183 | 7.3.4 | Test impact of upgrade in SH2 | 4d | 2014-10-07 08:00 A | 2014-10-10 17:00 A | 182FS+1d | 100% |  |  |  |  |
| 184 | 7.4 | **Upgrade Ancillary Systems' DB** | 3d | 2014-10-02 13:00 A | 2014-10-07 12:00 A |  | 100% |  |  |  |  |
| 185 | 7.4.1 | Upgrade Portal (JP3) DB attached to SF2 | 1d | 2014-10-02 13:00 A | 2014-10-03 12:00 A | 176FS+1d | 100% |  |  |  |  |
| 186 | 7.4.2 | Upgrade ADS (J11) DB attached to SF2/SF3/SH1/SH2 | 1d | 2014-10-02 13:00 A | 2014-10-03 12:00 A | 176FS+1d | 100% |  |  |  |  |
| 187 | 7.4.3 | Upgrade Portal (JP4) DB attached to SH1 | 1d | 2014-10-03 13:00 A | 2014-10-06 12:00 A | 185 | 100% |  |  |  |  |
| 188 | 7.4.4 | Upgrade Portal (J02) DB attached to SH2 | 1d | 2014-10-06 13:00 A | 2014-10-07 12:00 A | 187 | 100% |  |  |  |  |
| 189 | 7.5 | **Upgrade PS1 DB/OS** | 10d | 2014-10-13 08:00 A | 2014-10-26 09:30 A |  | 100% |  |  |  |  |
| 190 | 7.5.1 | Develop cut-over plan | 1d | 2014-10-13 08:00 A | 2014-10-13 17:00 A | 179 | 100% |  |  |  |  |
| 191 | 7.5.2 | Review cut-over plan | 1d | 2014-10-15 08:00 A | 2014-10-15 17:00 A | 190FS+1d | 100% |  |  |  |  |

| ID | WBS | Task | Type | Duration | Start | Finish | Predecessors | Complete | Remaining | Total slack | Free slack | Constraint | Calendar | Resources | Work | Actual work |
| --- | --- | --- | --- | --- | --- | --- | --- | --- | --- | --- | --- | --- | --- | --- | --- | --- |
| 192 | 7.5.3 | **Execute cut-over plan** |  | 0d | 2014-10-25 01:00 A | 2014-10-26 09:30 A |  | 100% |  |  |  |  |  |  |  |  |
| 193 | 7.5.3.1 | Upgrade PS1 ERP DB |  | 4h | 2014-10-25 01:00 A | 2014-10-25 05:00 A | 191FS+28d | 100% |  |  |  |  | 24 Hours |  |  |  |
| 194 | 7.5.3.2 | Upgrade PS1 Portal (JP6) DB |  | 1d | 2014-10-25 09:00 A | 2014-10-25 17:00 A | 191FS+29d | 100% |  |  |  |  | 24 Hours |  |  |  |
| 195 | 7.5.3.3 | Upgrade PS1 ADS (J31) DB |  | 1d | 2014-10-25 09:00 A | 2014-10-25 17:00 A | 191FS+29d | 100% |  |  |  |  | 24 Hours |  |  |  |
| 196 | 7.5.3.4 | Upgrade PS1 OS |  | 3d | 2014-10-25 05:00 A | 2014-10-26 05:00 A | 193 | 100% |  |  |  |  | 24 Hours |  |  |  |
| 197 | 7.5.3.5 | Post OS Upgrade SAP Activities |  | 3h | 2014-10-26 05:00 A | 2014-10-26 08:00 A | 196 | 100% |  |  |  |  | 24 Hours |  |  |  |
| 198 | 7.5.3.6 | IS Validations |  | 1h | 2014-10-26 08:00 A | 2014-10-26 09:00 A | 197 | 100% |  |  |  |  | 24 Hours |  |  |  |
| 199 | 7.5.3.7 | Open System to Community |  | 30min | 2014-10-26 09:00 A | 2014-10-26 09:30 A | 198 | 100% |  |  |  |  | 24 Hours |  |  |  |
| 200 | 8 | **Cleanup pending transports (to be moved before freeze)** |  | 15d | 2014-10-07 13:40 | 2014-10-28 13:40 | 60FS+20d |  |  | 68.54d |  |  |  |  | 224h |  |
| 201 | 8.1 | Create transport list |  | 1d | 2014-10-07 13:40 | 2014-10-08 13:40 | 14 |  |  | 82.54d |  |  |  | TransC | 8h |  |
| 202 | 8.2 | Determine status and plan for each |  | 3d | 2014-10-07 13:40 | 2014-10-10 13:40 | 14 |  |  | 68.54d | 0d |  |  | TransC | 24h |  |
| 203 | 8.3 | Execute pending transport plan |  | 12d | 2014-10-10 13:40 | 2014-10-28 13:40 | 202 |  |  | 68.54d |  |  |  | R3; TransC | 192h |  |
| 204 | 9 | **Refresh Staging Environment (SF3)** |  | 16d | 2014-09-22 08:00 A | 2014-10-13 17:00 |  | 73% | 4.25d | 79.12d |  |  |  |  | 55h | 50h |
| 205 | 9.1 | Execute pre-upgrade payroll simulation run (ZM) & store results (for comparison) |  | 1d | 2014-09-22 08:00 A | 2014-09-22 17:00 A | 8SS | 100% |  |  |  |  |  | HRP | 8h | 8h |
| 206 | 9.2 | Notify SAP Support Teams of Pending SF3 Outage |  | 1h | 2014-09-26 08:00 A | 2014-09-26 09:00 A | 8FS+3d | 100% |  |  |  |  |  | R3-1 | 1h | 1h |
| 207 | 9.3 | Sync up SF8 w/ PS1 transports |  | 1d | 2014-09-26 08:00 A | 2014-09-26 17:00 A | 8FS+3d | 100% |  |  |  |  |  |  |  |  |
| 208 | 9.4 | SF3 out of service/SF8 becomes system for OSS staging environment | milestone | 0h | 2014-09-27 17:00 A | 2014-09-27 17:00 A | 8FS+15d | 100% |  |  |  | finish no earlier than 2012-10-01 17:00 | 24 Hours |  |  |  |
| 209 | 9.5 | Refresh SF3 w/ PS1 Snapshot (identifeied in dates section) |  | 4d | 2014-09-29 08:00 A | 2014-10-02 17:00 A | 208 | 100% |  |  |  |  |  | R3 | 32h | 32h |
| 210 | 9.6 | Execute R3 Action Log |  | 4h | 2014-10-02 13:00 A | 2014-10-02 17:00 A | 209FF | 100% |  |  |  |  |  | R3 | 4h | 4h |
| 211 | 9.7 | Unlock Action Log participants |  | 1h | 2014-10-02 16:00 A | 2014-10-02 17:00 A | 209FF | 100% |  |  |  |  |  | R3-2 | 1h | 1h |
| 212 | 9.8 | Execute Refresh Action Log |  | 4h | 2014-10-02 13:00 A | 2014-10-02 17:00 A | 210FF | 100% |  |  |  |  |  | All | 4h | 4h |
| 213 | 9.9 | Import PS1/SF3 Transport Gap (9/25-10/9) |  | 4h | 2014-10-09 08:00 | 2014-10-09 12:00 | 209FS+4d |  |  | 81.62d |  |  |  | R3-1 | 4h |  |
| 214 | 9.10 | Holiday (Columbus Day) | milestone | 0h | 2014-10-13 17:00 | 2014-10-13 17:00 | 4 |  |  | 79.12d |  |  |  |  |  |  |
| 215 | 9.11 | Scramble sensitive data <hold off scrambling - perform after py sim run post SF3 upgrade> | milestone | 0d | 2014-10-02 17:00 | 2014-10-02 17:00 | 212 |  |  | 83d | 0d |  |  |  |  |  |
| 216 | 9.12 | Execute Financial Close <skip> |  | 1d | 2014-09-23 08:00 | 2014-09-23 17:00 | 205 |  |  | 93.12d |  |  |  |  |  |  |
| 217 | 9.13 | Execute DW Test Extract <skip> |  | 1d | 2014-09-23 08:00 | 2014-09-23 17:00 | 205 |  |  | 93d | 0d |  |  |  |  |  |
| 218 | 9.14 | Lock Action Log participants |  | 1h | 2014-09-24 08:00 | 2014-09-24 09:00 | 217 |  |  | 93d |  |  |  | R3-2 | 1h |  |

| ID | WBS | Task | Type | Duration | Start | Finish | Predecessors | Complete | Remaining | Total slack | Free slack | Calendar | Resources | Work | Actual work |
| --- | --- | --- | --- | --- | --- | --- | --- | --- | --- | --- | --- | --- | --- | --- | --- |
| 219 | 10 | **Obtain Final Support Pack** |  | 1d | 2014-10-09 08:00 | 2014-10-10 08:01 |  |  |  | 0d |  |  |  | 8h |  |
| 220 | 10.1 | October support pack available from SAP |  | 1min | 2014-10-09 08:00 | 2014-10-09 08:01 | 3 |  |  | 0d |  |  |  |  |  |
| 221 | 10.2 | Download support pack & most current SAP kernel patch |  | 1d | 2014-10-09 08:01 | 2014-10-10 08:01 | 220 |  |  | 0d |  |  | R3 | 8h |  |
| 222 | 11 | **Update Pre-staging Environment (SFK)** |  | 3d | 2014-10-10 08:01 A | 2014-10-14 17:00 | 219 | 27% | 2.2d | 78.12d |  |  |  | 20h | 16h |
| 223 | 11.1 | Apply SAP kernel update (most current version) |  | 4h | 2014-10-10 08:01 | 2014-10-10 13:01 |  |  |  | 327.5d | 0d | 24 Hours | R3-1 | 4h |  |
| 224 | 11.2 | Upgrade Oracle db to targeted level 11.2.0.4.0 | milestone | 0h | 2014-10-10 13:01 | 2014-10-10 13:01 | 223 |  |  | 328d | 0d | 24 Hours | R3-1 |  |  |
| 225 | 11.3 | Install Support stacks/packages |  | 36h | 2014-10-10 13:01 | 2014-10-12 01:01 | 224 |  |  | 328d | 3.87d | 24 Hours |  |  |  |
| 226 | 11.4 | **Update ancillary systems (Portal; ADS; SM)** |  | 1d | 2014-10-10 08:01 A | 2014-10-13 08:01 A |  | 100% |  |  |  |  | R3-3; R3-4 | 16h | 16h |
| 227 | 11.4.1 | **Portal** |  | 1d | 2014-10-10 08:01 A | 2014-10-13 08:01 A |  | 100% |  |  |  |  |  |  |  |
| 228 | 11.4.1.1 | Upgrade Linux OS |  | 1d | 2014-10-10 08:01 A | 2014-10-13 08:01 A |  | 100% |  |  |  |  |  |  |  |
| 229 | 11.4.1.2 | Upgrade Oracle DB |  | 1d | 2014-10-10 08:01 A | 2014-10-13 08:01 A |  | 100% |  |  |  |  |  |  |  |
| 230 | 11.4.1.3 | Upgrade SAP Portal |  | 1d | 2014-10-10 08:01 A | 2014-10-13 08:01 A |  | 100% |  |  |  |  |  |  |  |
| 231 | 11.4.1.4 | Apply OSS Notes (as required) |  | 1d | 2014-10-10 08:01 A | 2014-10-13 08:01 A |  | 100% |  |  |  |  |  |  |  |
| 232 | 11.5 | Validate security infrastructure (SNC) |  | 2d | 2014-10-13 08:00 | 2014-10-14 17:00 | 225 |  |  | 78.12d |  |  |  |  |  |
| 233 | 11.6 | Validate SAPGui interactions |  | 2d | 2014-10-13 08:00 | 2014-10-14 17:00 | 225 |  |  | 78.12d |  |  |  |  |  |
| 234 | 11.7 | Validate basic SAP functions work |  | 2d | 2014-10-13 08:00 | 2014-10-14 17:00 | 225 |  |  | 78.12d |  |  |  |  |  |
| 235 | 11.8 | SFK updated | milestone | 0h | 2014-10-13 08:01 | 2014-10-13 08:01 | 226 |  |  | 80.12d |  |  |  |  |  |
| 236 | 12 | **Update Staging Environment (SF3)** |  | 6d | 2014-10-10 08:01 | 2014-10-17 17:00 | 219 |  |  | 4d | 0d |  |  | 125h |  |
| 237 | 12.1 | Upgrade Oracle db to targeted level 11.2.0.4.0 |  | 8h | 2014-10-10 08:01 | 2014-10-13 08:01 | 219 |  |  | 12.5d | 0d | 24 Hours | R3-2 | 8h |  |
| 238 | 12.2 | Install Enhancement and/or Support Packs/Stack |  | 70h | 2014-10-13 08:01 | 2014-10-16 06:01 | 237 |  |  | 12.62d | 0d | 24 Hours | R3-1 | 6h |  |
| 239 | 12.3 | Apply SAP kernel update (most current version) |  | 2h | 2014-10-16 08:00 | 2014-10-16 10:00 | 238 |  |  | 5.75d |  |  | R3-1 | 2h |  |
| 240 | 12.4 | Back up SF3 |  | 2h | 2014-10-13 08:01 | 2014-10-13 10:01 | 237 |  |  | 8.75d |  |  |  |  |  |
| 241 | 12.5 | Update BSI ( most current TUBs) |  | 2h | 2014-10-13 08:01 | 2014-10-13 10:01 | 238SS |  |  | 12.62d | 0d | 24 Hours | R3-1 | 2h |  |
| 242 | 12.6 | Update ancillary systems (Portal - SPS 7; PI-ADS - OSS Notes; SM) |  | 1d | 2014-10-16 08:00 | 2014-10-16 17:00 | 238 |  |  | 5d |  |  | R3-1 [300%] | 24h |  |
| 243 | 12.7 | Produce SPAU report, Apply OSS notes |  | 1d | 2014-10-16 08:00 | 2014-10-16 17:00 | 238 |  |  | 5d |  |  | R3-4 | 8h |  |
| 244 | 12.8 | Post Support pack action log |  | 4h | 2014-10-13 10:01 | 2014-10-13 15:01 | 241 |  |  | 4.5d | 0d |  | R3-3 | 4h |  |
| 245 | 12.9 | Validate - external interfaces ITS, jco, mitid, fax. |  | 6h | 2014-10-13 15:01 | 2014-10-14 13:01 | 244 |  |  | 4.5d | 0d |  | R3-3 | 6h |  |
| 246 | 12.10 | Unlock Developers involved in SPAU analysis |  | 1h | 2014-10-14 13:01 | 2014-10-14 14:01 | 245 |  |  | 7.37d |  |  | R3-2 | 1h |  |
| 247 | 12.11 | Check, decide, apply MIT mods or use enhancement framework |  | 2d | 2014-10-15 08:00 | 2014-10-16 17:00 | 245FS+1d |  |  | 18d | 0d | 24 Hours | ABAP | 16h |  |
| 248 | 12.12 | SAP developer functionality validation |  | 2d | 2014-10-15 08:00 | 2014-10-16 17:00 | 247SS |  |  | 5d |  |  | ABAP [200%] | 32h |  |
| 249 | 12.13 | Execute post-upgrade payroll simulation run (ZM) & compare results |  | 1d | 2014-10-17 08:00 | 2014-10-17 17:00 | 247 |  |  | 4d |  |  | HRP | 8h |  |
| 250 | 12.14 | Execute post-upgrade DW extracts (limited testing - key extracts) |  | 1d | 2014-10-17 08:00 | 2014-10-17 17:00 | 247 |  |  | 4d | 0d |  | DW | 8h |  |
| 251 | 12.15 | SF3 updated | milestone | 0h | 2014-10-17 17:00 | 2014-10-17 17:00 | 250 |  |  | 4d |  |  |  |  |  |
| 252 | 13 | Development freeze begins (non-SP development is put on hold) | milestone | 0h | 2014-10-20 17:00 | 2014-10-20 17:00 | 236FS+1d |  |  | 4d | 0d |  |  |  |  |

Notes:
- 223: Allow for one hour installation time.
- 225: Allow for twekve hours.
- 226: R3 needs to review security notes related to PI/ADS components. / Application of SPS 6 to Portal in process (R3-4).
- 250: Cost element and profit center groups : ZWHCEHI / Payroll results: ZWHPAYROLL_RESULTS_NEW / Overhead: ZWHGETTE, ZWHOHSHT, ZWHOHRT, ZWHOHCRD, ZWHOHBAS, ZWHCTLGN

| ID | WBS | Task | Type | Duration | Start | Finish | Predecessors | Total slack | Free slack | Calendar | Resources | Work |
| --- | --- | --- | --- | --- | --- | --- | --- | --- | --- | --- | --- | --- |
| 253 | 14 | **Update Development Environment (SF2)** |  | 3d | 2014-10-20 17:00 | 2014-10-23 17:00 | 252 | 3.5d | 0d |  |  | 79h |
| 254 | 14.1 | Apply SAP kernel update (most current version) |  | 4h | 2014-10-20 17:00 | 2014-10-20 21:00 |  | 26d |  | 24 Hours | R3-1 | 4h |
| 255 | 14.2 | Install Support packages (Enh 6 + SP Stacks 4 + SP 50-53; EA15) |  | 24h | 2014-10-20 17:00 | 2014-10-21 17:00 |  | 17.75d | 1.88d | 24 Hours | R3-1 | 24h |
| 256 | 14.3 | Apply BSI Tax Factory Update |  | 2h | 2014-10-22 08:00 | 2014-10-22 10:00 | 255 | 15.88d | 0d | 24 Hours | R3-1 | 2h |
| 257 | 14.4 | Upgrade ERP Oracle db |  | 8h | 2014-10-22 10:00 | 2014-10-22 18:00 | 256 | 16.88d | 0d | 24 Hours | R3-4 | 8h |
| 258 | 14.5 | Back up database |  | 6h | 2014-10-22 18:00 | 2014-10-23 00:00 | 257 | 16.88d | 1d | 24 Hours | SO | 6h |
| 259 | 14.6 | Import transports from SF3 |  | 2h | 2014-10-23 08:00 | 2014-10-23 10:00 | 258 | 15.88d | 0d | 24 Hours | R3-1 | 2h |
| 260 | 14.7 | **Upgrade Portal (JP3) - skip2011** |  | 1d | 2014-10-23 08:00 | 2014-10-23 17:00 | 258SS | 3.5d |  |  |  | 14h |
| 261 | 14.7.1 | Apply SPS 7 |  | 6h | 2014-10-23 08:00 | 2014-10-23 15:00 |  | 3.75d |  |  | R3-4 | 6h |
| 262 | 14.7.2 | Upgrade Portal Oracle db |  | 8h | 2014-10-23 08:00 | 2014-10-23 17:00 |  | 3.5d |  |  | R3-4 | 8h |
| 263 | 14.8 | **Upgrade PI/ADS System (J11)** |  | 1d | 2014-10-23 08:00 | 2014-10-23 17:00 | 258SS | 3.5d |  |  |  | 15h |
| 264 | 14.8.1 | Upgrade kernel |  | 1h | 2014-10-23 08:00 | 2014-10-23 09:00 |  | 4.38d |  |  | R3-3 | 1h |
| 265 | 14.8.2 | Apply SPS 7 |  | 6h | 2014-10-23 08:00 | 2014-10-23 15:00 |  | 3.75d |  |  | R3-3 | 6h |
| 266 | 14.8.3 | Upgrade PI/ADS Oracle db (J01) |  | 8h | 2014-10-23 08:00 | 2014-10-23 17:00 |  | 3.5d |  |  | R3-3 | 8h |
| 267 | 14.9 | Execute action log (add updates if necessary) |  | 4h | 2014-10-23 10:00 | 2014-10-23 15:00 | 259 | 3.75d | 0d |  | R3-1 | 4h |
| 268 | 14.10 | SF2 updated | milestone | 0h | 2014-10-23 15:00 | 2014-10-23 15:00 | 267 | 3.75d |  |  |  |  |
| 269 | 15 | **Zuttreq updates** |  | 0.12d | 2014-10-24 08:00 | 2014-10-24 09:00 | 253 | 71d |  |  |  | 2h |
| 270 | 15.1 | Change target system for transport layer |  | 1h | 2014-10-24 08:00 | 2014-10-24 09:00 |  | 71d |  |  | R3-1 | 1h |
| 271 | 15.2 | Change target system in Zuttreq |  | 1h | 2014-10-24 08:00 | 2014-10-24 09:00 |  | 71d |  |  | ABAP Lead | 1h |
| 272 | 16 | **Unit Test Execution (performed in SF2)** |  | 6d | 2014-10-24 08:00 | 2014-10-31 17:00 | 253 | 3.5d | 0d |  |  | 184h |
| 273 | 16.1 | **Functional Tests** |  | 6d | 2014-10-24 08:00 | 2014-10-31 17:00 |  | 3.5d | 0d |  |  | 184h |
| 274 | 16.1.1 | Financial Unit Tests, Issue identification and retest |  | 6d | 2014-10-24 08:00 | 2014-10-31 17:00 |  | 3.5d |  |  | FIN | 48h |
| 275 | 16.1.2 | Logistics Unit Tests, Issue identification and retest |  | 6d | 2014-10-24 08:00 | 2014-10-31 17:00 |  | 3.5d |  |  | log | 48h |
| 276 | 16.1.3 | EHS Unit Tests, Issue identification and retest |  | 6d | 2014-10-24 08:00 | 2014-10-31 17:00 |  | 3.5d |  |  | EHS | 48h |
| 277 | 16.1.4 | HR-Payroll Unit Tests, Issue identification and retest |  | 6d | 2014-10-24 08:00 | 2014-10-31 17:00 |  | 3.5d |  |  | HRP [83.3%] | 40h |
| 278 | 16.2 | All functional teams ok environment and move to SIT |  | 4h | 2014-10-31 13:00 | 2014-10-31 17:00 | 273FF | 3.5d | 0d |  |  |  |
| 279 | 16.3 | Unit test complete | milestone | 0h | 2014-10-31 17:00 | 2014-10-31 17:00 | 278 | 3.5d | 0d |  |  |  |

| ID | WBS | Task | Type | Duration | Start | Finish | Predecessors | Total slack | Free slack | Calendar | Resources | Work |
| --- | --- | --- | --- | --- | --- | --- | --- | --- | --- | --- | --- | --- |
| 280 | 17 | **Refresh Test Environment (SH2)** |  | 7.25d | 2014-10-15 08:00 | 2014-10-24 10:00 | 247SS | 69.25d |  |  |  | 104h |
| 281 | 17.1 | Pre-update DW extracts (store for comparisons - from PS1) |  | 4h | 2014-10-15 08:00 | 2014-10-15 12:00 |  | 77.62d |  |  | DW | 4h |
| 282 | 17.2 | Confirm/Setup/update gateway components for new test system |  | 4h | 2014-10-15 08:00 | 2014-10-15 12:00 |  | 77.62d |  |  | IDD | 4h |
| 283 | 17.3 | Refresh SH2 w/ PS1 Snapshot (identified in dates section) |  | 30h | 2014-10-15 08:00 | 2014-10-20 15:00 |  | 285.25d | 0d | 24 Hours | OIS [320%] | 96h |
| 284 | 17.4 | Post Restore Activities |  | 2d | 2014-10-20 15:00 | 2014-10-22 15:00 | 283 | 69.25d | 0d |  |  |  |
| 285 | 17.5 | Import PS1/SH1 Transport Gap (monthly release 02) |  | 4h | 2014-10-22 15:00 | 2014-10-23 10:00 | 284 | 69.25d | 0d |  |  |  |
| 286 | 17.6 | Execute R3 Action Log |  | 4h | 2014-10-23 10:00 | 2014-10-23 15:00 | 285 | 69.25d | 0d |  |  |  |
| 287 | 17.7 | Execute Refresh Action Log |  | 4h | 2014-10-23 15:00 | 2014-10-24 10:00 | 286 | 69.25d | 0.75d |  |  |  |
| 288 | 18 | **Update Test Environment (SH2)** |  | 5.25d | 2014-10-24 17:00 | 2014-11-03 10:00 | 253FS+1d | 64.88d |  |  |  | 67h |
| 289 | 18.1 | Upgrade Oracle db |  | 8h | 2014-10-24 17:00 | 2014-10-25 01:00 | 287 | 291.75d | 1.25d | 24 Hours | R3-4 | 8h |
| 290 | 18.2 | Apply SAP kernel update |  | 2h | 2014-10-24 17:00 | 2014-10-24 19:00 | 287 | 290.5d | 0d | 24 Hours | R3-1 | 2h |
| 291 | 18.3 | Install Support packages |  | 12h | 2014-10-24 19:00 | 2014-10-25 07:00 | 290 | 290.5d | 0d | 24 Hours | R3-1 | 12h |
| 292 | 18.4 | Apply BSI Tax Factory Update |  | 2h | 2014-10-25 07:00 | 2014-10-25 09:00 | 291 | 290.5d | 0d | 24 Hours | R3-1 | 2h |
| 293 | 18.5 | Import transports from SF3 |  | 2h | 2014-10-25 09:00 | 2014-10-25 11:00 | 292 | 290.5d | 0d | 24 Hours | R3-1 | 2h |
| 294 | 18.6 | Back up database |  | 6h | 2014-10-25 11:00 | 2014-10-25 17:00 | 289, 293 | 290.5d | 4.88d | 24 Hours | SO | 6h |
| 295 | 18.7 | Execute post support pack action log (add updates if necessary) |  | 4h | 2014-10-27 08:00 | 2014-10-27 12:00 | 294 | 69.5d | 0d |  | R3 | 4h |
| 296 | 18.8 | Import transports from SF2 |  | 2h | 2014-10-31 17:00 | 2014-10-31 19:00 | 279 | 272.62d | 7.62d | 24 Hours | R3-1 | 2h |
| 297 | 18.9 | Import Production Transports from 10/29 - 10/31 |  | 2h | 2014-11-03 08:00 | 2014-11-03 10:00 | 296 | 64.88d |  |  |  |  |
| 298 | 18.10 | DW Schedule Extract Jobs |  | 1h | 2014-10-27 13:00 | 2014-10-27 14:00 | 295 | 69.5d |  |  |  |  |
| 299 | 18.11 | **Upgrade Portal (JP5)** |  | 1d | 2014-10-27 08:00 | 2014-10-27 17:00 |  | 69.12d |  |  |  | 14h |
| 300 | 18.11.1 | Apply SPS 7 |  | 6h | 2014-10-27 08:00 | 2014-10-27 15:00 |  | 69.38d |  |  | R3-4 | 6h |
| 301 | 18.11.2 | Upgrade Portal Oracle db |  | 8h | 2014-10-27 08:00 | 2014-10-27 17:00 |  | 69.12d |  |  | R3-4 | 8h |
| 302 | 18.12 | **Upgrade PI/ADS System** |  | 1d | 2014-10-27 08:00 | 2014-10-27 17:00 |  | 69.12d |  |  |  | 15h |
| 303 | 18.12.1 | Update kernel |  | 1h | 2014-10-27 08:00 | 2014-10-27 09:00 |  | 70d |  |  | R3-3 | 1h |
| 304 | 18.12.2 | Apply SPS 7 |  | 6h | 2014-10-27 08:00 | 2014-10-27 15:00 |  | 69.38d |  |  | R3-3 | 6h |
| 305 | 18.12.3 | Upgrade PI/ADS Oracle db |  | 8h | 2014-10-27 08:00 | 2014-10-27 17:00 |  | 69.12d |  |  | R3-3 | 8h |
| 306 | 19 | Production Transport Freeze Begins (last transports allowed into PS1) | milestone | 0d | 2014-10-30 17:00 | 2014-10-30 17:00 | 252FS+8d | 19d | 0d |  |  |  |

| ID | WBS | Task | Type | Duration | Start | Finish | Predecessors | Total slack | Free slack | Constraint | Calendar | Resources | Work |
| --- | --- | --- | --- | --- | --- | --- | --- | --- | --- | --- | --- | --- | --- |
| 307 | 20 | **Execute System Integration Tests (SH2)** |  | 21.5d | 2014-11-03 08:00 | 2014-12-02 12:00 | 272 | 3.5d | 0d |  |  |  | 228h |
| 308 | 20.1 | Holiday (Veterans Day) | milestone | 0d | 2014-11-10 17:00 | 2014-11-10 17:00 | 306FS+7d | 19d |  | start no earlier than 2012-11-12 17:00 |  |  |  |
| 309 | 20.2 | Post GUI message on prod support env indicating its use (SH2) |  | 1h | 2014-11-03 08:00 | 2014-11-03 09:00 |  | 24.88d |  |  |  |  |  |
| 310 | 20.3 | Execute Payroll comparison run |  | 5d | 2014-11-03 08:00 | 2014-11-07 17:00 |  | 3.5d | 0d |  |  | HRP | 40h |
| 311 | 20.4 | Execute data warehouse extracts |  | 1d | 2014-11-03 08:00 | 2014-11-03 17:00 | 310SS | 3.5d | 0d |  |  | DW | 8h |
| 312 | 20.5 | Execute FIN TB |  | 1d | 2014-11-03 08:00 | 2014-11-03 17:00 | 310SS | 23d | 0d |  |  | FIN-1 | 8h |
| 313 | 20.6 | Analyze data warehouse extracts comparison |  | 1d | 2014-11-04 08:00 | 2014-11-04 17:00 | 312 | 23d |  |  |  | DW | 8h |
| 314 | 20.7 | Analyze payroll comparison run |  | 3d | 2014-11-10 08:00 | 2014-11-12 17:00 | 310 | 17d |  |  |  | HRP | 24h |
| 315 | 20.8 | Financial Close (month of October) |  | 1d | 2014-11-10 08:00 | 2014-11-10 17:00 | 310 | 19d |  |  |  | FIN | 8h |
| 316 | 20.9 | Execute Automated Testing |  | 2d | 2014-11-10 08:00 | 2014-11-11 17:00 | 310 | 18d |  |  |  | QA-4 | 16h |
| 317 | 20.10 | Execute General SIT |  | 11d | 2014-11-04 08:00 | 2014-11-18 17:00 | 311 | 3.5d | 0d |  |  | All | 88h |
| 318 | 20.11 | Issue Retesting |  | 2d | 2014-11-19 08:00 | 2014-11-20 17:00 | 317 | 11d |  |  |  | All | 16h |
| 319 | 20.12 | Execute pre-update validation testing |  | 1d | 2014-11-20 08:00 | 2014-11-20 17:00 | 317FS+1d | 3.5d | 0d |  |  | Bus-Val | 8h |
| 320 | 20.13 | System Integration Test sign-off |  | 4h | 2014-11-21 08:00 | 2014-11-21 12:00 | 319 | 3.5d | 0d |  |  | All | 4h |
| 321 | 20.14 | SIT complete | milestone | 0h | 2014-11-21 12:00 | 2014-11-21 12:00 | 320 | 3.5d | 0d |  |  |  |  |
| 322 | 20.15 | Final preparation work |  | 1d | 2014-12-01 13:00 | 2014-12-02 12:00 | 321FS+6d | 3.5d |  |  |  |  |  |
| 323 | 21 | **Pre-cutover weekend activities** |  | 3.25d | 2014-11-26 08:00 | 2014-12-01 10:00 | 328SS-8d | 44.88d |  |  |  |  | 4h |
| 324 | 21.1 | Expand prod disc space to accommodate Enh Pack load |  | 1h | 2014-11-26 08:00 | 2014-11-26 09:00 |  | 44.88d | 0d |  |  | OIS | 1h |
| 325 | 21.2 | System message put out on SAP GUI |  | 1h | 2014-12-01 09:00 | 2014-12-01 10:00 | 324FS+3d | 44.88d |  |  |  | R3-1 | 1h |
| 326 | 21.3 | System message put out on SAPWeb & ESS&insideMIT pages |  | 1h | 2014-12-01 09:00 | 2014-12-01 10:00 | 324FS+3d | 44.88d |  |  |  | IDD | 1h |
| 327 | 21.4 | Send outage headsup message to community |  | 1h | 2014-12-01 09:00 | 2014-12-01 10:00 | 324FS+3d | 44.88d |  |  |  | PM | 1h |
| 328 | 22 | **Cutover weekend & Controlled Start** |  | 3d | 2014-12-05 20:00 | 2014-12-10 17:00 |  | 3d | 0d |  |  |  | 4h |
| 329 | 22.1 | Update production (detailed weekend cutover plan in a separate document) | milestone | 2d | 2014-12-05 20:00 | 2014-12-06 12:00 | 307FS+10d | 15.38d | 0d |  | 24 Hours |  |  |
| 330 | 22.2 | Production validation |  | 1d | 2014-12-06 20:00 | 2014-12-07 04:00 | 329FS+1d | 15.38d | 0d |  | 24 Hours | Bus [50%] | 4h |
| 331 | 22.3 | Go/No Go approval |  | 1h | 2014-12-07 04:00 | 2014-12-07 05:00 | 330 | 15.38d | 0d |  | 24 Hours |  |  |
| 332 | 22.4 | Updated production available | milestone | 0h | 2014-12-07 05:00 | 2014-12-07 05:00 | 331 | 4d | 0d |  |  |  |  |
| 333 | 22.5 | First Production pay run execution |  | 2d | 2014-12-09 08:00 | 2014-12-10 17:00 | 332FS+1d | 4d | 0d |  |  |  |  |
| 334 | 23 | Freezes End (development & production) | milestone | 0h | 2014-12-10 17:00 | 2014-12-10 17:00 | 333 | 4d | 0d |  |  |  |  |
| 335 | 24 | First Calendar 2015 Payrun Date | milestone | 0h | 2014-12-19 08:00 | 2014-12-19 08:00 | 7 | 31.12d |  |  |  |  |  |

| ID | WBS | Task | Duration | Start | Finish | Predecessors | Total slack | Free slack |
| --- | --- | --- | --- | --- | --- | --- | --- | --- |
| 336 | 25 | **Post go-live activities** | 33.12d | 2014-12-11 08:00 | 2015-01-27 09:00 |  | 4d |  |
| 337 | 25.1 | Install SAP GUI level 16 on EHS PCs (see RT # 1397279) | 2h | 2014-12-11 08:00 | 2014-12-11 10:00 | 334 | 36.88d |  |
| 338 | 25.2 | SH2 Status Change | 1h | 2014-12-11 08:00 | 2014-12-11 09:00 | 334 | 36.88d | 0d |
| 339 | 25.3 | SH1 Status Change | 1h | 2014-12-11 08:00 | 2014-12-11 09:00 | 334 | 37d |  |
| 340 | 25.4 | SF8 Status Change | 1h | 2014-12-11 08:00 | 2014-12-11 09:00 | 334 | 37d |  |
| 341 | 25.5 | Scramble SF3 | 4h | 2014-12-11 08:00 | 2014-12-11 12:00 | 334 | 36.62d |  |
| 342 | 25.6 | PS1 Snapshot for SF8/SH2 | 1h | 2014-12-25 08:00 | 2014-12-25 09:00 | 334FS+10d | 4d | 0d |
| 343 | 25.7 | SH2 System refresh & update | 10d | 2014-12-25 09:00 | 2015-01-08 09:00 | 342 | 4d | 0d |
| 344 | 25.8 | Zuttreq updates | 1h | 2014-12-11 09:00 | 2014-12-11 10:00 | 338 | 36.88d |  |
| 345 | 25.9 | Change target system in Zuttreq | 1h | 2014-12-11 09:00 | 2014-12-11 10:00 | 338 | 36.88d |  |
| 346 | 25.10 | SF8 System Refresh & Update | 10d | 2015-01-13 09:00 | 2015-01-27 09:00 | 343FS+3d | 4d |  |
